# Сопроводительный файл

How a schedule from MS Project changed from version to version. A marks actual dates.

## Version 1 (data date 2002-02-10, saved 2002-09-25, file 8.MPP)

| ID | WBS | Task | Duration | Start | Finish | Predecessors | Total float |
| --- | --- | --- | --- | --- | --- | --- | --- |
| 1 | 1 | **Планирование номера** | 13d | 2001-10-22 | 2001-11-07 |  | 0d |
| 2 |  | Сбор предложений от авторов | 5d | 2001-10-22 | 2001-10-26 |  | 0d |
| 3 |  | Подготовка плана номера | 3d | 2001-10-29 | 2001-10-31 | 2 | 0d |
| 4 |  | Предварительная редколлегия | 1d | 2001-11-01 | 2001-11-01 | 3 | 0d |
| 5 |  | Доработка планов с учетом замечаний | 3d | 2001-11-02 | 2001-11-06 | 4 | 0d |
| 6 |  | Редколлегия | 1d | 2001-11-07 | 2001-11-07 | 5 | 0d |
| 7 |  | План номера утвержден | 0d | 2001-11-07 | 2001-11-07 | 6 | 0d |
| 8 | 2 | **Подготовка материалов** | 37d | 2001-11-08 | 2001-12-28 | 7 | 0d |
| 9 | 2.1 | **Подготовка обложки** | 37d | 2001-11-08 | 2001-12-28 |  | 20d |
| 10 |  | Отбор модели | 5d | 2001-11-08 | 2001-11-14 |  | 48d |
| 11 |  | Фотосъемка модели | 4d | 2001-11-15 | 2001-11-20 | 10 | 48d |
| 12 |  | Подготовка анонсов материалов номера для обложки | 3d | 2001-12-21 | 2001-12-25 | 21FS-4d | 3d |
| 13 |  | Верстка обложки | 3d | 2001-12-26 | 2001-12-28 | 12 | 3d |
| 14 |  | Обложка готова | 0d | 2001-12-28 | 2001-12-28 | 13 | 3d |
| 15 | 2.2 | **Подготовка текстов** | 35d | 2001-11-08 | 2001-12-26 |  | 0d |
| 16 |  | Подготовка редакционных заданий | 3d | 2001-11-08 | 2001-11-12 |  | 0d |
| 17 |  | Рассылка заданий авторам | 2d | 2001-11-13 | 2001-11-14 | 16 | 0d |
| 18 |  | Утверждение заданий | 4d | 2001-11-15 | 2001-11-20 | 17 | 0d |
| 19 |  | Статьи в работе у авторов | 0d | 2001-11-20 | 2001-11-20 | 18 | 0d |
| 20 |  | Статьи поступили в редакцию | 0d | 2001-12-04 | 2001-12-04 | 19FS+10d | 0d |
| 21 |  | Редактирование материалов | 16d | 2001-12-05 | 2001-12-26 | 20 | 0d |
| 22 |  | Техническое редактирование | 14d | 2001-12-07 | 2001-12-26 | 21SS+2d | 0d |
| 23 |  | Тексты готовы | 0d | 2001-12-26 | 2001-12-26 | 22 | 22d |
| 24 |  | Подготовка материалов завершена | 0d | 2001-12-26 | 2001-12-26 | 22 | 22d |
| 25 | 3 | **Верстка журнала** | 18d | 2001-12-12 | 2002-01-04 |  | 0d |
| 26 |  | Обработка текста и иллюстраций | 14d | 2001-12-12 | 2001-12-31 | 22SS+3d | 0d |
| 27 |  | Вычитка | 14d | 2001-12-17 | 2002-01-03 | 26SS+3d | 15d |
| 28 |  | Сверка | 12d | 2001-12-20 | 2002-01-04 | 27SS+3d | 15d |
| 29 |  | Подготовка оглавления | 2d | 2002-01-01 | 2002-01-02 | 26 | 0d |
| 30 |  | Окончательная сборка | 2d | 2002-01-03 | 2002-01-04 | 29, 14 | 0d |
| 31 |  | Номер сверстан | 0d | 2002-01-04 | 2002-01-04 | 30 | 0d |
| 32 | 4 | **Предпечатная подготовка** | 15d | 2002-01-07 | 2002-01-25 | 31 | 0d |
| 33 |  | Конвертция сверстанного номера в формат Mac | 5d | 2002-01-07 | 2002-01-11 |  | 0d |
| 34 |  | Цветоделение | 7d | 2002-01-14 | 2002-01-22 | 33 | 0d |
| 35 |  | Коррекция | 7d | 2002-01-15 | 2002-01-23 | 34SS+1d | 0d |
| 36 |  | Вывод пленок | 7d | 2002-01-17 | 2002-01-25 | 35SS+2d | 0d |
| 37 |  | Номер готов к передаче в типографию | 0d | 2002-01-25 | 2002-01-25 | 36 | 0d |

## Version 2 (data date 2002-02-10, saved 2003-08-01, file ConstraintDates.mpp)

Last finish 2002-01-25 → 2002-04-19 (+84d).

Added:

| ID | Task | Duration | Start | Finish | Predecessors |
| --- | --- | --- | --- | --- | --- |
| 13 | Передача рекламных анонсов в предыдущий номер | 1d | 2002-03-11 | 2002-03-11 | 22FS-5% |

Changed:

| ID | Task | Start | Finish | Duration | Total float | Predecessors | Other |
| --- | --- | --- | --- | --- | --- | --- | --- |
| 1 | **Планирование номера** | 2001-10-22 → 2002-01-10 (+80d) | 2001-11-07 → 2002-01-28 (+82d) |  |  |  |  |
| 2 | Сбор предложений от авторов | 2001-10-22 → 2002-01-10 (+80d) | 2001-10-26 → 2002-01-16 (+82d) |  |  |  |  |
| 3 | Подготовка плана номера | 2001-10-29 → 2002-01-17 (+80d) | 2001-10-31 → 2002-01-21 (+82d) |  |  |  |  |
| 4 | Предварительная редколлегия | 2001-11-01 → 2002-01-22 (+82d) | 2001-11-01 → 2002-01-22 (+82d) |  |  |  |  |
| 5 | Доработка планов с учетом замечаний | 2001-11-02 → 2002-01-23 (+82d) | 2001-11-06 → 2002-01-25 (+80d) |  |  |  |  |
| 6 | Редколлегия | 2001-11-07 → 2002-01-28 (+82d) | 2001-11-07 → 2002-01-28 (+82d) |  |  |  |  |
| 7 | План номера утвержден | 2001-11-07 → 2002-01-28 (+82d) | 2001-11-07 → 2002-01-28 (+82d) |  |  |  |  |
| 8 | **Подготовка материалов** | 2001-11-08 → 2002-01-29 (+82d) | 2001-12-28 → 2002-03-20 (+82d) | 37d → 35d |  |  |  |
| 9 | **Подготовка обложки** | 2001-11-08 → 2002-02-01 (+85d) | 2001-12-28 → 2002-03-18 (+80d) | 37d → 30d | 20d → 0d |  |  |
| 10 | Отбор модели | 2001-11-08 → 2002-02-01 (+85d) | 2001-11-14 → 2002-02-04 (+82d) | 5d → 2d | 48d → 0d |  | constraint none → must start on 2002-02-01 |
| 11 | Фотосъемка модели | 2001-11-15 → 2002-02-05 (+82d) | 2001-11-20 → 2002-02-08 (+80d) |  | 48d → 28d |  |  |
| 12 | Подготовка анонсов материалов номера для обложки | 2001-12-21 → 2002-03-11 (+80d) | 2001-12-25 → 2002-03-13 (+78d) |  | 3d → 7d | 22FS-4d → 22FS-5% |  |
| 14 | Верстка обложки | 2001-12-26 → 2002-03-14 (+78d) | 2001-12-28 → 2002-03-18 (+80d) |  | 3d → 7d | 12 → 12, 11 |  |
| 15 | Обложка готова | 2001-12-28 → 2002-03-18 (+80d) | 2001-12-28 → 2002-03-18 (+80d) |  | 3d → 7d |  |  |
| 16 | **Подготовка текстов** | 2001-11-08 → 2002-01-29 (+82d) | 2001-12-26 → 2002-03-20 (+84d) |  |  |  |  |
| 17 | Подготовка редакционных заданий | 2001-11-08 → 2002-01-29 (+82d) | 2001-11-12 → 2002-01-31 (+80d) |  |  |  |  |
| 18 | Рассылка заданий авторам | 2001-11-13 → 2002-02-01 (+80d) | 2001-11-14 → 2002-02-04 (+82d) |  |  |  |  |
| 19 | Утверждение заданий | 2001-11-15 → 2002-02-05 (+82d) | 2001-11-20 → 2002-02-08 (+80d) |  |  |  |  |
| 20 | Статьи в работе у авторов | 2001-11-20 → 2002-02-08 (+80d) | 2001-11-20 → 2002-02-08 (+80d) |  |  |  |  |
| 21 | Статьи поступили в редакцию | 2001-12-04 → 2002-02-22 (+80d) | 2001-12-04 → 2002-02-22 (+80d) |  |  |  |  |
| 22 | Редактирование материалов | 2001-12-05 → 2002-02-26 (+83d) | 2001-12-26 → 2002-03-20 (+84d) |  |  |  |  |
| 23 | Техническое редактирование | 2001-12-07 → 2002-02-28 (+83d) | 2001-12-26 → 2002-03-20 (+84d) |  |  |  |  |
| 24 | Тексты готовы | 2001-12-26 → 2002-03-20 (+84d) | 2001-12-26 → 2002-03-20 (+84d) |  |  |  |  |
| 25 | Подготовка материалов завершена | 2001-12-26 → 2002-03-20 (+84d) | 2001-12-26 → 2002-03-20 (+84d) |  |  |  |  |
| 26 | **Верстка журнала** | 2001-12-12 → 2002-03-05 (+83d) | 2002-01-04 → 2002-03-29 (+84d) |  |  |  |  |
| 27 | Обработка текста и иллюстраций | 2001-12-12 → 2002-03-05 (+83d) | 2001-12-31 → 2002-03-25 (+84d) |  |  |  |  |
| 28 | Вычитка | 2001-12-17 → 2002-03-11 (+84d) | 2002-01-03 → 2002-03-28 (+84d) |  |  |  |  |
| 29 | Сверка | 2001-12-20 → 2002-03-14 (+84d) | 2002-01-04 → 2002-03-29 (+84d) |  |  |  |  |
| 30 | Подготовка оглавления | 2002-01-01 → 2002-03-26 (+84d) | 2002-01-02 → 2002-03-27 (+84d) |  |  |  |  |
| 31 | Окончательная сборка | 2002-01-03 → 2002-03-28 (+84d) | 2002-01-04 → 2002-03-29 (+84d) |  |  |  |  |
| 32 | Номер сверстан | 2002-01-04 → 2002-03-29 (+84d) | 2002-01-04 → 2002-03-29 (+84d) |  |  |  |  |
| 33 | **Предпечатная подготовка** | 2002-01-07 → 2002-04-01 (+84d) | 2002-01-25 → 2002-04-19 (+84d) |  |  |  |  |
| 34 | Конвертция сверстанного номера в формат Mac | 2002-01-07 → 2002-04-01 (+84d) | 2002-01-11 → 2002-04-05 (+84d) |  |  |  |  |
| 35 | Цветоделение | 2002-01-14 → 2002-04-08 (+84d) | 2002-01-22 → 2002-04-16 (+84d) |  |  |  |  |
| 36 | Коррекция | 2002-01-15 → 2002-04-09 (+84d) | 2002-01-23 → 2002-04-17 (+84d) |  |  |  |  |
| 37 | Вывод пленок | 2002-01-17 → 2002-04-11 (+84d) | 2002-01-25 → 2002-04-19 (+84d) |  |  |  |  |
| 38 | Номер готов к передаче в типографию | 2002-01-25 → 2002-04-19 (+84d) | 2002-01-25 → 2002-04-19 (+84d) |  |  |  | constraint none → finish no later than 2002-04-20 |
